# Plataforma de Interfonía VoIP

Schedule from MS Project, 2005-09-01 to 2006-02-28, 5 hours a day, costs in €, A marks actual dates.

## Calendars

- Calendar 2: Mon-Thu 09:00-14:00; Fri-Sun off. Exceptions (off unless hours are given): 2005-09-01 09:00-14:00, 2005-09-02, 2005-09-05 to 2005-09-08 09:00-14:00, 2005-09-09, 2005-09-12 to 2005-09-15 09:00-14:00, 2005-09-16, 2005-09-19 to 2005-09-22 09:00-14:00, 2005-09-23, 2005-09-26 to 2005-09-29 09:00-14:00, 2005-09-30, 2005-10-03 to 2005-10-06 09:00-14:00, 2005-10-07, 2005-10-10 to 2005-10-13 09:00-14:00, 2005-10-14, 2005-10-17 to 2005-10-20 09:00-14:00, 2005-10-21, 2005-10-24 to 2005-10-27 09:00-14:00, 2005-10-28, 2005-10-31 to 2005-11-03 09:00-14:00, 2005-11-04, 2005-11-07 to 2005-11-10 09:00-14:00, 2005-11-11, 2005-11-14 to 2005-11-17 09:00-14:00, 2005-11-18, 2005-11-21 to 2005-11-24 09:00-14:00, 2005-11-25, 2005-11-28 to 2005-12-01 09:00-14:00, 2005-12-02, 2005-12-05 to 2005-12-08 09:00-14:00, 2005-12-09, 2005-12-12 to 2005-12-15 09:00-14:00, 2005-12-16, 2005-12-19 to 2005-12-22 09:00-14:00, 2005-12-23, 2005-12-26 to 2005-12-27 09:00-14:00, 2005-12-28 to 2005-12-31, 2006-01-02 to 2006-01-05 09:00-14:00, 2006-01-06, 2006-01-09 to 2006-01-12 09:00-14:00, 2006-01-13, 2006-01-16 to 2006-01-19 09:00-14:00, 2006-01-20, 2006-01-23 to 2006-01-26 09:00-14:00, 2006-01-27, 2006-01-30 to 2006-02-02 09:00-14:00, 2006-02-03, 2006-02-06 to 2006-02-09 09:00-14:00, 2006-02-10, 2006-02-13 to 2006-02-16 09:00-14:00, 2006-02-17, 2006-02-20 to 2006-02-23 09:00-14:00, 2006-02-24, 2006-02-27 to 2006-02-28 09:00-14:00.

## Resources

| Resource | Group | Rate |
| --- | --- | --- |
| Personal Computer | EQUIPAMIENTOS ACCESORIOS | 1000 |
| Switch 20 puertos | EQUIPAMIENTOS ACCESORIOS | 100 |
| Quintum Tenor Gatekeeper | EQUIPAMIENTOS INSTALADOS | 639.26 |
| Quintum Tenor ASG200 | EQUIPAMIENTOS INSTALADOS | 389.95 |
| Quintum Tenor AXG800 | EQUIPAMIENTOS INSTALADOS | 1045.43 |
| Licencia SJPhone | EQUIPAMIENTOS INSTALADOS | 95 |
| Interfono Viking 1600 A | EQUIPAMIENTOS INSTALADOS | 15.2 |
| Teléfono IP Telkus Totalfon IP5000 | EQUIPAMIENTOS INSTALADOS | 137.9 |
| Teléfono IP Micronet 5100SP | EQUIPAMIENTOS INSTALADOS | 153.2 |
| Teléfono IP Cisco 7905G | EQUIPAMIENTOS INSTALADOS | 253.43 |
| Teléfono Analógico Alcatel Temporis 45 | EQUIPAMIENTOS INSTALADOS | 43.95 |
| Cables Ethernet | EQUIPAMIENTOS ACCESORIOS | 20 |
| Cables de Pares | EQUIPAMIENTOS ACCESORIOS | 7.5 |
| Desplazamientos y dietas | DESPLAZAMIENTOS Y DIETAS | 341 |
| Salarios | SALARIOS | 4.71 |
| Estructura de soporte de interfonos | EQUIPAMIENTOS INSTALADOS | 1088 |
| Material básico de oficina | EQUIPAMIENTOS ACCESORIOS | 59 |

## Schedule

| ID | Task | Type | Duration | Start | Finish | Predecessors | Complete | Baseline start | Baseline finish | Baseline duration | Constraint | Deadline | Resources | Work | Actual work | Cost | Baseline cost | Actual cost |
| --- | --- | --- | --- | --- | --- | --- | --- | --- | --- | --- | --- | --- | --- | --- | --- | --- | --- | --- |
| 1 | Comienzo fase Preliminar | milestone | 0d | 2005-09-01 A | 2005-09-01 A |  | 100% | 2005-09-01 | 2005-09-01 | 0d |  |  |  |  |  |  |  |  |
| 2 | Acomodación a los recursos de la empresa |  | 2d | 2005-09-01 A | 2005-09-05 A |  | 100% | 2005-09-01 | 2005-09-06 | 2d |  | 2006-04-19 | Personal Computer; Material básico de oficina |  |  | 1,059 | 416,000 | 1,059 |
| 3 | Estudio de las tecnologías |  | 7d | 2005-09-07 A | 2005-09-19 A | 2 | 100% | 2005-09-07 | 2005-09-19 | 7d | start no earlier than 2005-09-06 |  |  |  |  |  |  |  |
| 4 | Análisis del mercado VoIP |  | 2d | 2005-09-20 A | 2005-09-21 A | 3 | 100% | 2005-09-20 | 2005-09-21 | 2d |  |  |  |  |  |  |  |  |
| 5 | Estudio de equipos Quintum Tenor |  | 8d | 2005-09-22 A | 2005-10-05 A | 4 | 100% | 2005-09-22 | 2005-10-10 | 8d | start no earlier than 2005-09-26 |  | Quintum Tenor Gatekeeper; Quintum Tenor ASG200; Quintum Tenor AXG800 |  |  | 2,074.64 | 1,536,000 | 2,074.64 |
| 6 | Construcción maqueta interfonía |  | 25d | 2005-09-28 A | 2005-11-09 A | 4 | 100% | 2005-09-28 | 2005-11-09 | 20d | finish no earlier than 2005-11-03 |  | Switch 20 puertos; Cables Ethernet; Cables de Pares; Interfono Viking 1600 A [400%] |  |  | 188.3 | 2,400,000 | 188.3 |
| 7 | Comienzo de la fase de Diseño | milestone | 0d | 2005-10-11 A | 2005-10-11 A |  | 100% | 2005-10-11 | 2005-10-11 | 0d |  |  |  |  |  |  |  |  |
| 8 | Selección de terminales |  | 8d | 2005-10-11 A | 2005-10-24 A | 5 | 100% | 2005-10-11 | 2005-10-24 | 8d | start no earlier than 2005-10-07 |  |  |  |  |  |  |  |
| 9 | Adquisición de terminales |  | 8d | 2005-10-25 A | 2005-11-07 A | 8 | 100% | 2005-10-25 | 2005-11-09 | 8d |  |  | Teléfono IP Telkus Totalfon IP5000; Teléfono IP Micronet 5100SP; Teléfono IP Cisco 7905G |  |  | 544.53 | 960,000 | 544.53 |
| 10 | Montaje maqueta completa |  | 2d | 2005-11-10 A | 2005-11-14 A | 9, 6 | 100% | 2005-11-10 | 2005-11-15 | 2d |  |  | Quintum Tenor Gatekeeper; Quintum Tenor ASG200 [700%]; Quintum Tenor AXG800; Interfono Viking 1600 A [400%]; Teléfono Analógico Alcatel Temporis 45 |  |  | 4,519.09 | 240,000 | 4,519.09 |
| 11 | Pruebas FAT |  | 10d | 2005-11-16 A | 2005-12-01 A | 10 | 100% | 2005-11-16 | 2005-12-01 | 10d |  |  | Licencia SJPhone; Interfono Viking 1600 A [1300%] |  |  | 292.6 |  | 292.6 |
| 12 | Comienzo de la fase de Instalación y redacción de informes | milestone | 0d | 2005-12-08 A | 2005-12-08 A |  | 100% | 2005-12-05 | 2005-12-05 | 0d |  |  |  |  |  |  |  |  |
| 13 | Instalación y redacción de informes |  | 45d | 2005-12-08 A | 2006-02-28 A | 11 | 100% | 2005-12-05 | 2005-12-22 | 9d |  |  | Estructura de soporte de interfonos |  |  | 1,088 | 1,080,000 | 1,088 |
| 14 | Pruebas SAT |  | 8d | 2005-12-14 A | 2005-12-27 A | 11 | 100% | 2005-12-14 | 2005-12-27 | 8d |  |  | Desplazamientos y dietas |  |  | 341 |  | 341 |
| 15 | Duración total: 6 meses |  | 101d | 2005-09-01 A | 2006-02-28 A |  | 100% |  |  |  | start no earlier than 2005-09-01 |  | Salarios [132.3%] | 668h | 668h | 3,143.53 |  | 3,143.53 |

Notes:
- 2: Durante esta fase, el becario debe conocer la empresa, su composición, los departamentos, y, sobre todo, de qué recursos dispone en su seno, a quién puede acudir, qué protocolos existen.
- 3: Estudio en profundidad de los protocolos H.323 y SIP, así como de las teconlogías VoIP en el mercado
- 4: Estudio de las posibilidades del mercado VoIP, fabricantes y ofertas en relación al protocolo H.323, características habituales de equipos, equipos de bajo y alto coste, equipos orientados a PYMES y a corporaciones
- 5: Estudio en profundidad de las opciones de configuración, firmwares, interfaces, características, etc de los equipos Quintum Tenor que van a utilizarse en los proyectos de interfonía; manuales y pruebas
- 6: Esta fase se desarrolla en paralelo con el estudio de las necesidades de los proyectos requeridos, y consiste en el desarrollo de una maqueta de interfonía a la cual poco a poco van añadiéndose nuevos elementos, probándose, examinando en profundidad su comportamiento, etc
- 8: A continuación vuelve a examinarse el mercado de la VoIP para encontrar los terminales más apropiados a los equipos Quintum Tenor y a los proyectos Barrio de las Letras y Estación Bailén Metro de Valencia: se requieren terminales económicos, compatibles, y acordes a las necesidades.
- 9: Compra o petición en pruebas de terminales, y pruebas de los mismos en la maqueta de interfonía, comprobando interoperabilidad, robustez, funcionamiento; examinando trazas y resolviendo errores.
- 10: Una vez finalizada la selección de los terminales y su validación, se pasa a montar una maqueta completa, con todos los equipos destinados a la futura instalación, sobre una red cargada (la de la empresa), para cada proyecto.
- 11: Factory Acceptance Test, pruebas en fábrica sobre las maquetas completas: durante tres semanas se someterá la maqueta a pruebas como resistencia y robustez temporal, generadores de llamadas, generadores de tráfico masivo, desconexiones de la corriente eléctrica y de la red, y todo tipo de llamadas dentro de la propia maqueta; se medirán niveles de calidad en la forma de retardos, nivel de ruido y ecos, y calificación subjetiva del audio. Y en caso de errores, se subsanarán.
- 13: Los instaladores llevarán los equipos a las salas de máquinas, y los conectarán siguiendo las indicaciones del becario. Éste sólo tomará parte activa en la instalación durante las pruebas SAT, y hasta entonces sólo tendrá que dedicarse a redactar memorias de manuales de configuración y resolución de problemas, y protocolos de pruebas.
- 14: Se realizarán pruebas de conectividad, de calidad del audio, de comunicación. Son pruebas mucho más sencillas que las FAT, orientadas a resolver dificultades que no se habían pensado por sencillas o triviales
